# Building

Schedule from MS Project, 2001-06-04 to 2001-12-03.
Course Technology

## Calendars

- Standard: Mon-Fri 08:00-12:00, 13:00-17:00; Sat-Sun off.

## Schedule

| ID | WBS | Task | Duration | Start | Finish | Predecessors | Total slack | Free slack | Work |
| --- | --- | --- | --- | --- | --- | --- | --- | --- | --- |
| 1 | 1 | **Interiors Remodeling & Related Exterior Work, 8 Apt. Units** | 131d | 2001-06-04 | 2001-12-03 |  | 0d |  | 1504h |
| 2 | 1.1 | Interior Demolition | 1d | 2001-06-04 | 2001-06-04 |  | 0d |  |  |
| 3 | 1.2 | Replace Fascia and Soffit | 3d | 2001-06-05 | 2001-06-07 | 2 | 89d | 0d |  |
| 4 | 1.3 | Roofing | 3d | 2001-06-08 | 2001-06-12 | 3 | 89d |  |  |
| 5 | 1.4 | **Interiors Rough-In** | 87d | 2001-06-05 | 2001-10-03 |  | 0d |  |  |
| 6 | 1.4.1 | Cut and Infill Masonry per Plans | 1d | 2001-06-05 | 2001-06-05 | 2 | 0d |  |  |
| 7 | 1.4.2 | Trench Out Concrete Slab per Plans | 1d | 2001-06-06 | 2001-06-06 | 6 | 0d |  |  |
| 8 | 1.4.3 | Rough Plumbing below grade | 2d | 2001-06-07 | 2001-06-08 | 7 | 0d |  |  |
| 9 | 1.4.4 | City Inspection of Rough Plumbing below grade | 1d | 2001-06-11 | 2001-06-11 | 8 | 0d |  |  |
| 10 | 1.4.5 | Infill Conrete | 1d | 2001-06-12 | 2001-06-12 | 9 | 0d |  |  |
| 11 | 1.4.6 | Rough Framing | 20d | 2001-06-13 | 2001-07-10 | 10 | 0d |  |  |
| 12 | 1.4.7 | Rough-In Mechanical (Ducting, etc.) | 15d | 2001-07-11 | 2001-07-31 | 11 | 0d |  |  |
| 13 | 1.4.8 | Rough-In Plumbing | 15d | 2001-08-01 | 2001-08-21 | 12 | 0d |  |  |
| 14 | 1.4.9 | Rough-In Fire Sprinkler | 15d | 2001-08-22 | 2001-09-11 | 13 | 0d |  |  |
| 15 | 1.4.10 | Rough-In Electrical and Fire Alarm Wiring & Devices | 10d | 2001-09-12 | 2001-09-25 | 14 | 0d |  |  |
| 16 | 1.4.11 | Firestop | 2d | 2001-09-26 | 2001-09-27 | 12, 13, 14, 15 | 3d |  |  |
| 17 | 1.4.12 | City Inspection of Rough-In Mech/Electrical/Plumbing | 1d | 2001-09-26 | 2001-09-26 | 15, 12, 13, 14 | 0d |  |  |
| 18 | 1.4.13 | Frame Soffit Areas | 4d | 2001-09-27 | 2001-10-02 | 17 | 0d |  |  |
| 19 | 1.4.14 | City Inspection Of Rough Framing | 1d | 2001-10-03 | 2001-10-03 | 11, 16, 18 | 0d |  |  |
| 20 | 1.5 | **Interior Finish Work** | 34d | 2001-10-02 | 2001-11-16 |  | 0d |  |  |
| 21 | 1.5.1 | Install Windows and Exterior Doors | 2d | 2001-10-02 | 2001-10-04 | 22SF, 11 | 27d | 0d |  |
| 22 | 1.5.2 | Install Insulation | 4d | 2001-10-04 | 2001-10-09 | 5 | 0d |  |  |
| 23 | 1.5.3 | Hang Drywall | 8d | 2001-10-10 | 2001-10-19 | 22 | 0d |  |  |
| 24 | 1.5.4 | Finish & Texture Drywall | 10d | 2001-10-16 | 2001-10-29 | 23SS+4d | 0d |  |  |
| 25 | 1.5.5 | Paint | 4d | 2001-10-23 | 2001-10-26 | 24SS+5d | 0d |  |  |
| 26 | 1.5.6 | Install Underlayment | 3d | 2001-10-25 | 2001-10-29 | 25SS+2d | 1d | 0d |  |
| 27 | 1.5.7 | Install Electrical Fixtures | 4d | 2001-10-29 | 2001-11-01 | 25 | 0d |  |  |
| 28 | 1.5.8 | Install Water Heaters | 2d | 2001-10-30 | 2001-10-31 | 26 | 1d |  |  |
| 29 | 1.5.9 | Install Furnaces and final sheet metal plenums | 3d | 2001-10-04 | 2001-10-08 | 21 | 27d | 15d |  |
| 30 | 1.5.10 | Affix Sprinkler Heads | 1d | 2001-10-29 | 2001-10-29 | 25 | 12d | 0d |  |
| 31 | 1.5.11 | Activate HVAC and Fire Protection System | 2d | 2001-10-30 | 2001-10-31 | 29, 30, 57 | 12d |  |  |
| 32 | 1.5.12 | Install Flooring | 8d | 2001-11-02 | 2001-11-13 | 26, 27, 28 | 0d |  |  |
| 33 | 1.5.13 | Finish Carpentry (Install Cabinets & Interior Doors) | 8d | 2001-11-06 | 2001-11-15 | 32SS+2d | 0d |  |  |
| 34 | 1.5.14 | Install Wood Base and Handrails | 4d | 2001-11-12 | 2001-11-15 | 33SS+2d, 35FF+1d | 1d |  |  |
| 35 | 1.5.15 | Affix Duct Registers | 1d | 2001-11-14 | 2001-11-14 | 25, 26, 32 | 1d | 0d |  |
| 36 | 1.5.16 | Accessories and Blinds | 3d | 2001-11-06 | 2001-11-08 | 33SS | 6d |  |  |
| 37 | 1.5.17 | Plumbing Fixtures | 4d | 2001-11-13 | 2001-11-16 | 33FF+1d | 0d |  |  |
| 38 | 1.6 | City Inspections of Finished Product | 1d | 2001-11-19 | 2001-11-19 | 20 | 0d |  |  |
| 39 | 1.7 | Correct any City Punchlist Items | 3d | 2001-11-20 | 2001-11-22 | 38 | 0d |  |  |
| 40 | 1.8 | City Re-Inspects | 1d | 2001-11-23 | 2001-11-23 | 39 | 0d |  |  |
| 41 | 1.9 | Final Cleaning and Preparation for Turnover | 5d | 2001-11-26 | 2001-11-30 | 40 | 0d |  |  |
| 42 | 1.10 | Turn building over to Owner | 1d | 2001-12-03 | 2001-12-03 | 41 | 0d |  |  |

| ID | WBS | Task | Type | Duration | Start | Finish | Predecessors | Total slack | Free slack | Work |
| --- | --- | --- | --- | --- | --- | --- | --- | --- | --- | --- |
| 43 | 2 | **Site Work and Primary Exterior Work** |  | 106d | 2001-06-04 | 2001-10-29 |  | 25d | 0d | 1640h |
| 44 | 2.1 | Pour Fence Foundations |  | 1d | 2001-06-04 | 2001-06-04 | 2SS | 7d | 0d |  |
| 45 | 2.2 | Fence Posts Masonry |  | 8d | 2001-06-05 | 2001-06-14 | 44 | 7d | 0d |  |
| 46 | 2.3 | Install Iron Fencing |  | 80d | 2001-06-15 | 2001-10-04 | 45 | 7d |  |  |
| 47 | 2.4 | Existing Parking Lot Demolition |  | 5d | 2001-06-04 | 2001-06-08 | 2SS | 84d | 0d |  |
| 48 | 2.5 | Install Parking Lot Curbs |  | 5d | 2001-06-11 | 2001-06-15 | 47 | 84d | 0d |  |
| 49 | 2.6 | Parking Lot Asphalt |  | 2d | 2001-06-18 | 2001-06-19 | 48 | 84d |  |  |
| 50 | 2.7 | **Exterior Work** |  | 86d | 2001-06-04 | 2001-10-01 |  | 45d |  | 608h |
| 51 | 2.7.1 | Locate and Disconnect Utilities |  | 1d | 2001-06-04 | 2001-06-04 | 2SS | 64d | 0d |  |
| 52 | 2.7.2 | Selective Demolition per Plans |  | 1d | 2001-06-05 | 2001-06-05 | 51 | 64d | 0d |  |
| 53 | 2.7.3 | Establish Initial Rough Grade |  | 2d | 2001-06-06 | 2001-06-07 | 52 | 64d | 0d |  |
| 54 | 2.7.4 | Stair Foundations |  | 3d | 2001-06-08 | 2001-06-12 | 53 | 64d | 0d |  |
| 55 | 2.7.5 | Fabricate Metal Stairs to match Field Conditions |  | 10d | 2001-06-04 | 2001-06-15 |  | 56d | 0d |  |
| 56 | 2.7.6 | **Utilities to Building from Street** |  | 79d | 2001-06-13 | 2001-10-01 |  | 25d |  |  |
| 57 | 2.7.6.1 | Fire Service Lines |  | 5d | 2001-06-13 | 2001-06-19 | 54 | 64d | 39d |  |
| 58 | 2.7.6.2 | Gas Service (by local Utility Company) |  | 3d | 2001-09-27 | 2001-10-01 | 17 | 25d | 0d |  |
| 59 | 2.7.6.3 | Electrical Service (by local Electrical Company) |  | 2d | 2001-09-27 | 2001-09-28 | 17 | 26d | 1d |  |
| 60 | 2.7.7 | Erect Metal Stairs in place |  | 10d | 2001-06-18 | 2001-06-29 | 6, 55 | 56d | 0d |  |
| 61 | 2.7.8 | Wood Decking for Stairs |  | 5d | 2001-07-02 | 2001-07-06 | 60 | 69d | 0d |  |
| 62 | 2.7.9 | Paint Stairs |  | 2d | 2001-07-09 | 2001-07-10 | 61 | 69d |  |  |
| 63 | 2.8 | **Common Area Courtyard** |  | 20d | 2001-10-02 | 2001-10-29 |  | 25d |  |  |
| 64 | 2.8.1 | Re-establish Rough Grade |  | 5d | 2001-10-02 | 2001-10-08 | 57, 58, 59, 60 | 25d | 0d |  |
| 65 | 2.8.2 | Pour Foundations for Bus Shelters |  | 3d | 2001-10-02 | 2001-10-04 | 64SS | 39d | 0d |  |
| 66 | 2.8.3 | Form & Pour Sidewalks |  | 5d | 2001-10-09 | 2001-10-15 | 64 | 25d | 0d |  |
| 67 | 2.8.4 | Masonry for Bus Shelters |  | 2d | 2001-10-05 | 2001-10-08 | 65 | 39d | 0d |  |
| 68 | 2.8.5 | Roof Framing and Roofing for Shelters |  | 1d | 2001-10-09 | 2001-10-09 | 67 | 39d |  |  |
| 69 | 2.8.6 | Final Grading |  | 2d | 2001-10-16 | 2001-10-17 | 66 | 25d | 0d |  |
| 70 | 2.8.7 | Plant Trees and Shrubs |  | 5d | 2001-10-18 | 2001-10-24 | 69 | 25d | 0d |  |
| 71 | 2.8.8 | Sod and Seed areas per Plans |  | 2d | 2001-10-25 | 2001-10-26 | 70 | 25d | 0d |  |
| 72 | 2.8.9 | Set up Site Furniture |  | 1d | 2001-10-29 | 2001-10-29 | 71 | 25d |  |  |
| 73 | 3 | All Interior and Exterior Building-related Work Complete | milestone | 0d | 2001-12-03 | 2001-12-03 | 1, 50 | 0d |  |  |
| 74 | 4 | All Site Work complete | milestone | 0d | 2001-10-29 | 2001-10-29 | 43 | 25d |  |  |
| 75 | 5 | Required Contract Completion Date | milestone | 0d | 2001-12-03 | 2001-12-03 | 73, 74 | 0d |  |  |
