# KitchenSOL

Schedule from MS Project, 2002-01-02 to 2002-01-12.
Course Technology

## Calendars

- Construction: Mon-Fri 18:00-22:00; Sat-Sun 08:00-20:00.
- Standard: Mon-Fri 08:00-12:00, 13:00-17:00; Sat-Sun off.

## Schedule

| ID | WBS | Task | Type | Duration | Start | Finish | Predecessors | Total slack | Calendar |
| --- | --- | --- | --- | --- | --- | --- | --- | --- | --- |
| 1 | 1 | **Procure Financing** |  | 1d | 2002-01-02 08:00 | 2002-01-02 17:00 |  | 0d |  |
| 2 | 1 | Gather financial information together to apply for a loan |  | 4h | 2002-01-02 08:00 | 2002-01-02 12:00 |  | 0d |  |
| 3 | 2 | Meet with the Bank to apply for a loan |  | 4h | 2002-01-02 13:00 | 2002-01-02 17:00 | 2 | 0d |  |
| 4 | 1.3 | Financing Obtained | milestone | 0d | 2002-01-02 17:00 | 2002-01-02 17:00 | 3 | 0d |  |
| 5 | 2 | **Construction Phase** |  | 8.5d | 2002-01-02 18:00 | 2002-01-12 20:00 | 1 | 0d | Construction |
| 6 | 4 | Tear out existing fixtures, cabinets and floor coverings |  | 8h | 2002-01-02 18:00 | 2002-01-03 22:00 |  | 0d | Construction |
| 7 | 5 | Patch or replace drywall as necessary |  | 8h | 2002-01-04 18:00 | 2002-01-05 12:00 | 6 | 0d | Construction |
| 8 | 6 | Install new light fixtures |  | 4h | 2002-01-05 12:00 | 2002-01-05 16:00 | 7 | 0d | Construction |
| 9 | 8 | Install Cabinets & Countertops |  | 8h | 2002-01-05 16:00 | 2002-01-06 12:00 | 8 | 0d | Construction |
| 10 | 9 | Install Kitchen Sink |  | 4h | 2002-01-06 12:00 | 2002-01-06 16:00 | 9 | 0d | Construction |
| 11 | 2.6 | Install Garbage Disposal |  | 2h | 2002-01-06 16:00 | 2002-01-06 18:00 | 10 | 0d | Construction |
| 12 | 10 | Install ceramic tile |  | 8h | 2002-01-06 18:00 | 2002-01-08 20:00 | 11 | 0d | Construction |
| 13 | 11 | Paint Window and Door Trim |  | 2h | 2002-01-08 20:00 | 2002-01-08 22:00 | 12 | 0d | Construction |
| 14 | 12 | Put up Wallpaper |  | 4h | 2002-01-10 18:00 | 2002-01-10 22:00 | 13FS+1ed | 0d | Construction |
| 15 | 13 | Install floor covering and wall base |  | 8h | 2002-01-11 18:00 | 2002-01-12 12:00 | 14 | 0d | Construction |
| 16 | 16 | Caulk |  | 4h | 2002-01-12 12:00 | 2002-01-12 16:00 | 15 | 0d | Construction |
| 17 | 17 | Clean |  | 4h | 2002-01-12 16:00 | 2002-01-12 20:00 | 16 | 0d | Construction |
| 18 | 3 | All Work Complete | milestone | 0d | 2002-01-12 20:00 | 2002-01-12 20:00 | 5 | 0d |  |
