# KitchenSOL

Schedule from MS Project, 2002-01-02 to 2002-01-12, costs in $.
Course Technology

## Calendars

- Standard: Mon-Fri 08:00-12:00, 13:00-17:00; Sat-Sun off.
- Construction: Mon-Fri 18:00-22:00; Sat-Sun 08:00-20:00.

## Resources

| Resource | Rate |
| --- | --- |
| carl rebman |  |
| bob jones |  |
| the banker |  |
| drywall patch | 30 |
| plumbing | 600 |
| electrical | 250 |
| ceramic tile | 100 |
| paint | 35 |
| wallpaper | 75 |
| floor covering | 280 |
| caulk | 20 |

## Schedule

| ID | WBS | Task | Type | Duration | Start | Finish | Predecessors | Total slack | Calendar | Resources | Work | Cost |
| --- | --- | --- | --- | --- | --- | --- | --- | --- | --- | --- | --- | --- |
| 1 | 1 | **Procure Financing** |  | 1d | 2002-01-02 18:00 | 2002-01-03 22:00 |  | 0d |  |  | 8h | 35 |
| 2 | 1 | Gather financial information together to apply for a loan |  | 4h | 2002-01-02 18:00 | 2002-01-02 22:00 |  | 0d |  | carl rebman | 4h | 35 |
| 3 | 2 | Meet with the Bank to apply for a loan |  | 4h | 2002-01-03 18:00 | 2002-01-03 22:00 | 2 | 0d |  | carl rebman | 4h |  |
| 4 | 1.3 | Financing Obtained | milestone | 0d | 2002-01-03 22:00 | 2002-01-03 22:00 | 3 | 1d |  | the banker |  |  |
| 5 | 2 | **Construction Phase** |  | 7.5d | 2002-01-04 18:00 | 2002-01-12 20:00 | 1 | 0d | Construction |  | 64h | 5,000 |
| 6 | 4 | Tear out existing fixtures, cabinets and floor coverings |  | 8h | 2002-01-04 18:00 | 2002-01-05 12:00 |  | 0d | Construction | carl rebman | 8h |  |
| 7 | 5 | Patch or replace drywall as necessary |  | 8h | 2002-01-05 12:00 | 2002-01-05 20:00 | 6 | 0d | Construction | carl rebman; drywall patch | 8h | 30 |
| 8 | 6 | Install new light fixtures |  | 4h | 2002-01-06 08:00 | 2002-01-06 12:00 | 7 | 0d | Construction | bob jones; electrical | 4h | 350 |
| 9 | 8 | Install Cabinets & Countertops |  | 4h | 2002-01-06 12:00 | 2002-01-06 16:00 | 8 | 0d | Construction | bob jones; carl rebman | 8h | 3,072 |
| 10 | 9 | Install Kitchen Sink |  | 4h | 2002-01-06 16:00 | 2002-01-06 20:00 | 9 | 0d | Construction | bob jones; plumbing | 4h | 700 |
| 11 | 2.6 | Install Garbage Disposal |  | 2h | 2002-01-07 18:00 | 2002-01-07 20:00 | 10 | 0d | Construction | bob jones | 2h | 50 |
| 12 | 10 | Install ceramic tile |  | 4h | 2002-01-07 20:00 | 2002-01-08 20:00 | 11 | 0d | Construction | bob jones; ceramic tile; carl rebman | 8h | 172 |
| 13 | 11 | Paint Window and Door Trim |  | 2h | 2002-01-08 20:00 | 2002-01-08 22:00 | 12 | 0d | Construction | carl rebman; paint | 2h | 35 |
| 14 | 12 | Put up Wallpaper |  | 4h | 2002-01-10 18:00 | 2002-01-10 22:00 | 13FS+1ed | 0d | Construction | carl rebman; wallpaper | 4h | 75 |
| 15 | 13 | Install floor covering and wall base |  | 8h | 2002-01-11 18:00 | 2002-01-12 12:00 | 14 | 0d | Construction | bob jones; floor covering | 8h | 424 |
| 16 | 16 | Caulk |  | 4h | 2002-01-12 12:00 | 2002-01-12 16:00 | 15 | 0d | Construction | bob jones; caulk | 4h | 92 |
| 17 | 17 | Clean |  | 4h | 2002-01-12 16:00 | 2002-01-12 20:00 | 16 | 0d | Construction | carl rebman | 4h |  |
| 18 | 3 | All Work Complete | milestone | 0d | 2002-01-12 20:00 | 2002-01-12 20:00 | 5 | 0d |  |  |  |  |
